# Hyper-v Cloud Deployment Guides - Project Plan Template

Schedule from MS Project, 2008-01-07 to 2008-04-02.

## Calendars

- Standard: Mon-Fri 08:00-12:00, 13:00-17:00; Sat-Sun off.

## Schedule

| ID | WBS | Task | Duration | Start | Finish | Predecessors | Total slack | Free slack |
| --- | --- | --- | --- | --- | --- | --- | --- | --- |
| 1 | 1 | **Plan Track** | 35.5d | 2008-01-07 | 2008-02-25 |  | 0d |  |
| 2 | 1.1 | Create Master Project Schedule | 0.5d | 2008-01-07 | 2008-01-07 |  | 35d |  |
| 3 | 1.2 | **Virtualization Infrastructure Design** | 9.5d | 2008-01-07 | 2008-01-18 |  | 0d |  |
| 4 | 1.2.1 | **Host Server Sizing** | 9.5d | 2008-01-07 | 2008-01-18 |  | 0d |  |
| 5 | 1.2.1.1 | Review Architecture and Sizing Guide | 0.5d | 2008-01-07 | 2008-01-07 |  | 0d |  |
| 6 | 1.2.1.2 | Create Host Server Storage Design | 4d | 2008-01-07 | 2008-01-11 | 5 | 0d |  |
| 7 | 1.2.1.3 | Create Host Server Build Design | 3d | 2008-01-11 | 2008-01-16 | 6 | 0d |  |
| 8 | 1.2.1.4 | Create Host Server Security Design | 2d | 2008-01-16 | 2008-01-18 | 7 | 0d |  |
| 9 | 1.2.2 | **Virtualization Design and Standards** | 2d | 2008-01-07 | 2008-01-08 |  | 33.5d |  |
| 10 | 1.2.2.1 | Document Naming Standards for Guests, Disks, Networks, and so on | 0.5d | 2008-01-07 | 2008-01-07 |  | 33.5d | 0d |
| 11 | 1.2.2.2 | Document Virtual Machine Defaults | 0.5d | 2008-01-07 | 2008-01-07 | 10 | 33.5d | 0d |
| 12 | 1.2.2.3 | Document Hyper-V Standard Configuration | 1d | 2008-01-08 | 2008-01-08 | 11 | 33.5d |  |
| 13 | 1.2.3 | **Self Service Portal 2.0 Planning** | 1d | 2008-01-09 | 2008-01-10 |  |  |  |
| 14 | 1.2.3.1 | Review Topology Options | 1d | 2008-01-09 | 2008-01-10 |  | 0d |  |
| 15 | 1.2.3.2 | Review partner solutions in storage and network tools for SSP 2.0 (optional) | 1d | 2008-01-09 | 2008-01-10 |  | 0d |  |
| 16 | 1.2.3.3 | Create Server Topology | 1d | 2008-01-09 | 2008-01-10 |  | 0d |  |
| 17 | 1.2.3.4 | Create SSP Server Hardware Design | 1d | 2008-01-09 | 2008-01-10 |  | 0d |  |
| 18 | 1.2.3.5 | Create SSP Security Design | 1d | 2008-01-09 | 2008-01-10 |  | 0d |  |
| 19 | 1.2.3.6 | Create SSP Dashboard Design | 2d | 2008-01-09 | 2008-01-11 |  | -1d | 0d |
| 20 | 1.2.4 | **Management Infrastructure Design** | 9d | 2008-01-07 | 2008-01-17 |  | 26.5d |  |
| 21 | 1.2.4.1 | **Design System Center Virtual Machine Manager Implementation** | 4d | 2008-01-07 | 2008-01-10 |  | 26.5d | 0d |
| 22 | 1.2.4.1.1 | Design and Document Virtual Machine Templates | 1d | 2008-01-07 | 2008-01-07 |  | 26.5d | 0d |
| 23 | 1.2.4.1.2 | Design and Document ISO Image Management | 1d | 2008-01-08 | 2008-01-08 | 22 | 26.5d | 0d |
| 24 | 1.2.4.1.3 | Design Security Model for Virtualization Usage and Administration | 2d | 2008-01-09 | 2008-01-10 | 23 | 26.5d |  |

| ID | WBS | Task | Duration | Start | Finish | Predecessors | Total slack | Free slack |
| --- | --- | --- | --- | --- | --- | --- | --- | --- |
| 25 | 1.2.4.2 | **Design Self Service Portal 2.0 Implementation** | 1d | 2008-01-07 | 2008-01-07 |  | 34.5d |  |
| 26 | 1.2.4.2.1 | Design and Document Security Groups and Service Accounts | 1d | 2008-01-07 | 2008-01-07 |  | 34.5d |  |
| 27 | 1.2.4.2.2 | **Design and Document Storage Management** | 1d | 2008-01-07 | 2008-01-07 |  | 34.5d |  |
| 28 | 1.2.4.2.2.1 | Design integration of partner storage tools for SSP 2.0 (optional) | 1d | 2008-01-07 | 2008-01-07 |  | 34.5d |  |
| 29 | 1.2.4.2.3 | **Design and Document Networking Management** | 1d | 2008-01-07 | 2008-01-07 |  | 34.5d |  |
| 30 | 1.2.4.2.3.1 | Design integration of partner networking tools for SSP 2.0 (optional) | 1d | 2008-01-07 | 2008-01-07 |  | 34.5d |  |
| 31 | 1.2.4.2.4 | Design and Document SSP Dashboard Deployment | 1d | 2008-01-07 | 2008-01-07 |  | 34.5d |  |
| 32 | 1.2.4.2.5 | Design and Document Business Units, Environments | 1d | 2008-01-07 | 2008-01-07 |  | 34.5d |  |
| 33 | 1.2.4.3 | **Design Physical to Virtual Migration Process** | 5d | 2008-01-11 | 2008-01-17 | 21 | 26.5d |  |
| 34 | 1.2.4.3.1 | Determine Disk Space Requirements | 1d | 2008-01-11 | 2008-01-11 |  | 28.5d | 0d |
| 35 | 1.2.4.3.2 | Determine Physical to Virtual Cutover Process | 2d | 2008-01-14 | 2008-01-15 | 34 | 28.5d |  |
| 36 | 1.2.4.3.3 | Document Physical to Virtual Migration Process | 5d | 2008-01-11 | 2008-01-17 |  | 26.5d |  |
| 37 | 1.2.5 | **Virtualization Infrastructure Benchmarking** | 5d | 2008-01-07 | 2008-01-11 |  | 30.5d |  |
| 38 | 1.2.5.1 | Update Lab Implementation with Selected Host Hardware | 2d | 2008-01-07 | 2008-01-08 |  | 30.5d | 0d |
| 39 | 1.2.5.2 | Perform Host Server Benchmarking | 2d | 2008-01-09 | 2008-01-10 | 38 | 30.5d | 0d |
| 40 | 1.2.5.3 | Perform Guest Server Benchmarking | 1d | 2008-01-11 | 2008-01-11 | 39 | 30.5d |  |
| 41 | 1.3 | **Other Infrastructure Planning Considerations** | 12d | 2008-01-18 | 2008-02-05 |  | 0d |  |
| 42 | 1.3.1 | **Server Consolidation Planning** | 12d | 2008-01-18 | 2008-02-05 | 4 | 0d |  |
| 43 | 1.3.1.1 | Generate Consolidation Candidates by Location Reports | 2d | 2008-01-18 | 2008-01-22 |  | 0d |  |
| 44 | 1.3.1.2 | Calculate Current Candidate Workload by Location | 3d | 2008-01-22 | 2008-01-25 | 43 | 0d |  |
| 45 | 1.3.1.3 | Determine Host Server Architecture Pattern by Location | 5d | 2008-01-25 | 2008-02-01 | 44 | 0d |  |
| 46 | 1.3.1.4 | Calculate Host Servers Required by Location | 2d | 2008-02-01 | 2008-02-05 | 45 | 0d |  |
| 47 | 1.4 | **Migration Planning** | 14d | 2008-02-05 | 2008-02-25 | 42 | 0d |  |
| 48 | 1.4.1 | **Physical to Virtual Migration Plan** | 5d | 2008-02-05 | 2008-02-12 |  | 0d |  |
| 49 | 1.4.1.1 | Determine Candidates Requiring Offline P2V | 3d | 2008-02-05 | 2008-02-08 |  | 0d |  |
| 50 | 1.4.1.2 | Determine Candidates able to Go Live Immediately After P2V Migration | 2d | 2008-02-08 | 2008-02-12 | 49 | 0d |  |
| 51 | 1.4.2 | Create a Migration Schedule by Location | 3d | 2008-02-12 | 2008-02-15 | 48 | 0d |  |
| 52 | 1.4.3 | Create a Communication Plan for the Implementation and Consolidation | 3d | 2008-02-15 | 2008-02-20 | 51 | 0d |  |
| 53 | 1.4.4 | Create a Staffing and Training Plan for the Implementation and Consolidation | 3d | 2008-02-20 | 2008-02-25 | 52 | 0d |  |

| ID | WBS | Task | Type | Duration | Start | Finish | Predecessors | Total slack | Free slack |
| --- | --- | --- | --- | --- | --- | --- | --- | --- | --- |
| 54 | 2 | **Build Track** |  | 9d | 2008-02-25 | 2008-03-07 | 1 | 0d |  |
| 55 | 2.1 | **Host Server Infrastructure Build** |  | 9d | 2008-02-25 | 2008-03-07 |  | 0d |  |
| 56 | 2.1.1 | All Hardware and Software Delivered to Planned Locations | milestone | 0d | 2008-02-25 | 2008-02-25 |  | 0d |  |
| 57 | 2.1.2 | Host Server Storage Implementation |  | 5d | 2008-02-25 | 2008-03-03 | 56 | 0d |  |
| 58 | 2.1.3 | Host Server Implementation |  | 4d | 2008-03-03 | 2008-03-07 | 57 | 0d |  |
| 59 | 2.2 | **Management Infrastructure Build** |  | 3d | 2008-02-25 | 2008-02-28 | 56 | 6d |  |
| 60 | 2.2.1 | System Center Virtual Machine Manager Implementation |  | 3d | 2008-02-25 | 2008-02-28 |  | 6d |  |
| 61 | 2.3 | **Self-Service Infrastructure Build** |  | 3d | 2008-02-25 | 2008-02-28 |  | 6d |  |
| 62 | 2.3.1 | Install SSP 2.0 in chosen topology |  | 3d | 2008-02-25 | 2008-02-28 |  | 6d |  |
| 63 | 2.3.2 | Install and integrate partner solutions for storage and networking with SSP 2.0 (optional) |  | 1d | 2008-02-25 | 2008-02-26 |  | 8d |  |
| 64 | 2.3.3 | Create an environment within portal |  | 1d | 2008-02-25 | 2008-02-26 |  | 8d |  |
| 65 | 2.3.4 | Assign storage resources to environment |  | 1d | 2008-02-25 | 2008-02-26 |  | 8d |  |
| 66 | 2.3.5 | Assign networking resources to environment |  | 1d | 2008-02-25 | 2008-02-26 |  | 8d |  |
| 67 | 2.3.6 | Assign VM templates to environment |  | 1d | 2008-02-25 | 2008-02-26 |  | 8d |  |
| 68 | 2.4 | **SSP Dashboard Configuration** |  | 2d | 2008-02-25 | 2008-02-27 |  | 7d |  |
| 69 | 2.4.1 | Install SharePoint Services 3.0 or SharePoint Portal Server 2007 for use with Dashboard |  | 2d | 2008-02-25 | 2008-02-27 |  | 7d |  |
| 70 | 2.4.2 | Install SSP Dashboard |  | 1d | 2008-02-25 | 2008-02-26 |  | 8d |  |
| 71 | 2.5 | <New Task> |  | 1d | 2008-02-25 | 2008-02-26 |  | 8d |  |
| 72 | 3 | **Stabilize Track** |  | 15d | 2008-03-07 | 2008-03-28 | 54 | 0d |  |
| 73 | 3.1 | **Host Server Infrastructure Testing** |  | 5d | 2008-03-07 | 2008-03-14 |  | 10d |  |
| 74 | 3.1.1 | Host Server Storage Infrastructure Testing |  | 2d | 2008-03-07 | 2008-03-11 |  | 10d | 0d |
| 75 | 3.1.2 | Host Server Infrastructure Testing |  | 3d | 2008-03-11 | 2008-03-14 | 74 | 10d |  |
| 76 | 3.2 | **Management Infrastructure Testing** |  | 8d | 2008-03-07 | 2008-03-19 |  | 7d |  |
| 77 | 3.2.1 | System Center Virtual Machine Manager Testing |  | 4d | 2008-03-07 | 2008-03-13 |  | 7d | 0d |
| 78 | 3.2.2 | System Center Virtual Machine Manager Self Service Portal 2.0 Testing |  | 2d | 2008-03-13 | 2008-03-17 | 77 | 7d | 0d |
| 79 | 3.2.3 | Physical to Virtual Migration Testing |  | 2d | 2008-03-17 | 2008-03-19 | 78 | 7d |  |

| ID | WBS | Task | Duration | Start | Finish | Predecessors | Total slack | Free slack |
| --- | --- | --- | --- | --- | --- | --- | --- | --- |
| 80 | 3.3 | **PILOT Production Migration** | 15d | 2008-03-07 | 2008-03-28 |  | 0d |  |
| 81 | 3.3.1 | Document Pilot Success Criteria | 0.5d | 2008-03-07 | 2008-03-07 |  | 11.5d | 0d |
| 82 | 3.3.2 | Document Pilot Test Cases | 2d | 2008-03-10 | 2008-03-11 | 81 | 11.5d | 0d |
| 83 | 3.3.3 | Choose Pilot Location and Consolidation Candidates | 0.5d | 2008-03-12 | 2008-03-12 | 82 | 11.5d | 0d |
| 84 | 3.3.4 | Create Pilot Migration Schedule | 0.5d | 2008-03-12 | 2008-03-12 | 83 | 11.5d |  |
| 85 | 3.3.5 | Perform Pilot P2V Migrations | 5d | 2008-03-07 | 2008-03-14 |  | 0d |  |
| 86 | 3.3.6 | Perform Pilot Virtualization Management Test Cases | 2d | 2008-03-14 | 2008-03-18 | 85 | 0d |  |
| 87 | 3.3.7 | Perform Pilot Virtualization Disaster Recovery Test Cases | 3d | 2008-03-18 | 2008-03-21 | 86 | 0d |  |
| 88 | 3.3.8 | Verify All Pilot Processes and Procedures | 2d | 2008-03-21 | 2008-03-25 | 87 | 0d |  |
| 89 | 3.3.9 | Document Pilot Test Results | 2d | 2008-03-25 | 2008-03-27 | 88 | 0d |  |
| 90 | 3.3.10 | Update All Documentation with Lessons Learned | 1d | 2008-03-27 | 2008-03-28 | 89 | 0d |  |
| 91 | 4 | **Deploy Track** | 3d | 2008-03-28 | 2008-04-02 | 72 | 0d |  |
| 92 | 4.1 | **Create Deployment Teams** | 3d | 2008-03-28 | 2008-04-02 |  | 0d |  |
| 93 | 4.1.1 | Determine Consulting Staffing Requirements | 2d | 2008-03-28 | 2008-04-01 |  | 1d |  |
| 94 | 4.1.2 | Determine Customer Staffing Requirements | 3d | 2008-03-28 | 2008-04-02 |  | 0d |  |
| 95 | 4.2 | **Physical to Virtual Migration** | 1d | 2008-03-28 | 2008-03-31 |  | 2d |  |
| 96 | 4.2.1 | Location 2 Physical to Virtual Migration | 1d | 2008-03-28 | 2008-03-31 |  | 2d |  |
| 97 | 4.2.2 | Location 3 Physical to Virtual Migration | 1d | 2008-03-28 | 2008-03-31 |  | 2d |  |
| 98 | 4.2.3 | Location 4 Physical to Virtual Migration | 1d | 2008-03-28 | 2008-03-31 |  | 2d |  |
| 99 | 4.3 | **Self Service Portal Deployment Tasks** | 1d | 2008-03-28 | 2008-03-31 |  | 2d |  |
| 100 | 4.3.1 | Harden SSP 2.0 (Configure SSL, Disable ISAPI handlers) | 1d | 2008-03-28 | 2008-03-31 |  | 2d |  |
| 101 | 4.3.2 | Implement backup and operational task plan | 1d | 2008-03-28 | 2008-03-31 |  | 2d |  |
| 102 | 4.3.3 | **Create production environments** | 1d | 2008-03-28 | 2008-03-31 |  | 2d |  |
| 103 | 4.3.3.1 | Assign storage resources to environment | 1d | 2008-03-28 | 2008-03-31 |  | 2d |  |
| 104 | 4.3.3.2 | Assign networking resources to environment | 1d | 2008-03-28 | 2008-03-31 |  | 2d |  |
| 105 | 4.3.3.3 | Assign load balancer resources to environment | 1d | 2008-03-28 | 2008-03-31 |  | 2d |  |
| 106 | 4.3.3.4 | Assign VM templates to environment | 1d | 2008-03-28 | 2008-03-31 |  | 2d |  |

| ID | WBS | Task | Duration | Start | Finish | Total slack |
| --- | --- | --- | --- | --- | --- | --- |
| 107 | 4.3.4 | **SSP Dashboard Configuration** | 1d | 2008-03-28 | 2008-03-31 | 2d |
| 108 | 4.3.4.1 | Configure Data Sets | 1d | 2008-03-28 | 2008-03-31 | 2d |
| 109 | 4.3.4.2 | Construct Data Set Queries | 1d | 2008-03-28 | 2008-03-31 | 2d |
| 110 | 4.3.4.3 | Configure Data Display (graphs, grids, etc...) | 1d | 2008-03-28 | 2008-03-31 | 2d |
| 111 | 4.3.4.4 | Configure Access Permissions for Users and Groups | 1d | 2008-03-28 | 2008-03-31 | 2d |
| 112 | 5 | **Governance Track** | 30d | 2008-01-07 | 2008-02-15 | 32.5d |
| 113 | 5.1 | Change Management | 30d | 2008-01-07 | 2008-02-15 | 32.5d |
| 114 | 5.2 | Contract Management | 30d | 2008-01-07 | 2008-02-15 | 32.5d |
| 115 | 5.3 | Cost Management | 30d | 2008-01-07 | 2008-02-15 | 32.5d |
| 116 | 5.4 | Issue Management | 30d | 2008-01-07 | 2008-02-15 | 32.5d |
| 117 | 5.5 | Resource Management | 30d | 2008-01-07 | 2008-02-15 | 32.5d |
| 118 | 5.6 | Risk Management | 30d | 2008-01-07 | 2008-02-15 | 32.5d |
| 119 | 5.7 | Scope Management | 30d | 2008-01-07 | 2008-02-15 | 32.5d |
| 120 | 5.8 | Stakeholder Management | 30d | 2008-01-07 | 2008-02-15 | 32.5d |
